# MSP4 start file project 2013

Schedule from MS Project, 2015-01-02 to 2016-01-27, costs in $.
Zuma Project
CSUF

## Calendars

- Standard: Mon-Fri 08:00-12:00, 13:00-17:00; Sat-Sun off. Exceptions (off unless hours are given): 2015-05-25 (Memorial day), 2015-07-03 (hoilday day befor 4th of july), 2015-09-07 (Labor day), 2015-11-26 (Thanks giving), 2015-12-25 (Christmas).

## Resources

| Resource | Rate |
| --- | --- |
| marketing specialist | 60 |
| design engineer | 90 |
| development engineer | 80 |
| industrial engineer | 70 |
| purchasing agent | 50 |
| Extra marketing specialist | 70 |
| Extra design engineer | 100 |
| Extra development engineer | 90 |
| Extra industrial engineer | 80 |

## Schedule

| ID | WBS | Task | Duration | Start | Finish | Predecessors | Total slack | Free slack | Resources | Work | Cost |
| --- | --- | --- | --- | --- | --- | --- | --- | --- | --- | --- | --- |
| 1 | 1 | **Product development project** | 274d | 2015-01-02 | 2016-01-27 |  | 0d |  |  | 16640h | 1,266,000 |
| 2 | 1.1 | Market analysis | 25d | 2015-01-02 | 2015-02-05 |  | 0d |  | marketing specialist [400%] | 800h | 48,000 |
| 3 | 1.2 | product design | 40d | 2015-02-06 | 2015-04-02 | 2 | 20d |  | marketing specialist; design engineer [400%]; development engineer [200%]; industrial engineer; purchasing agent | 2880h | 224,000 |
| 4 | 1.3 | Manufacturing study | 40d | 2015-02-06 | 2015-04-30 | 2 | 0d |  | industrial engineer [400%]; development engineer [200%] | 960h | 70,400 |
| 5 | 1.4 | Product design selection | 10d | 2015-05-01 | 2015-05-14 | 3, 4 | 0d |  | marketing specialist [200%]; design engineer [300%]; development engineer [200%]; industrial engineer [200%]; purchasing agent [25%] | 740h | 56,200 |
| 6 | 1.5 | Detailed marketing plan | 20d | 2015-05-15 | 2015-07-29 | 5 | 126d |  | marketing specialist [400%]; Extra marketing specialist | 400h | 24,800 |
| 7 | 1.6 | Manufacturing process | 60d | 2015-05-15 | 2015-08-26 | 5 | 0d |  | design engineer; development engineer [200%]; industrial engineer [400%] | 1680h | 127,200 |
| 8 | 1.7 | Detailed product design | 42d | 2015-05-15 | 2015-07-15 | 5 | 20d | 0d | marketing specialist [200%]; design engineer [400%]; development engineer [200%]; industrial engineer [200%]; purchasing agent [25%]; Extra design engineer; Extra development engineer | 4116h | 330,120 |
| 9 | 1.8 | Test prototype | 10d | 2015-07-16 | 2015-07-29 | 8 | 20d |  | design engineer [300%]; development engineer [200%] | 400h | 34,400 |
| 10 | 1.9 | Finalized product design | 25d | 2015-08-27 | 2015-10-01 | 7, 9 | 0d |  | marketing specialist [200%]; design engineer [300%]; development engineer [300%]; industrial engineer [200%]; purchasing agent | 2200h | 164,000 |
| 11 | 1.10 | Order components | 7d | 2015-10-22 | 2015-10-30 | 10 | 13d |  | purchasing agent | 56h | 2,800 |
| 12 | 1.11 | Order production equipment | 14d | 2015-10-02 | 2015-10-21 | 10 | 0d |  | purchasing agent | 112h | 5,600 |
| 13 | 1.12 | Install production equipment | 27d | 2015-12-18 | 2016-01-26 | 11FS+20d, 12FS+40d | 0d |  | development engineer [300%]; industrial engineer [400%]; design engineer; Extra industrial engineer; Extra development engineer | 2160h | 168,480 |
| 14 | 1.13 | Celebrate | 1d | 2016-01-27 | 2016-01-27 | 6, 13 | 0d |  | design engineer [400%]; development engineer [400%]; industrial engineer [400%]; marketing specialist [400%]; purchasing agent | 136h | 10,000 |
